# 07_01_02_01_2015-04-24

Schedule from MS Project, 2013-01-29 to 2017-06-19, A marks actual dates.

## Calendars

- Standard: Mon-Fri 08:00-12:00, 13:00-17:00; Sat-Sun off.

## Resources

| Resource |
| --- |
| ENMA_Scientist |
| LOIS_Scientist |
| LOLI_Engineer (Master) |
| LOLI_Scientist |
| Manufacturing modified parts |
| Assembly and alignment |
| Commissioning without beam |
| CSTI_Mechanic |
| CSTI_Technician |
| ENMD_Engineer (Bachelor) |
| ENMI_Engineer (Master) |
| LOEP_Engineer (Master) |
| LOEP_Technician |
| LOBI_Engineer (Bachelor) |
| LOBI_Mechanic |
| LOBI_Scientist |
| LOBI_Technician |
| CSVS_Technician |
| CSCO_Engineer (Master) |
| VT_Engineer |

## Schedule

| ID | WBS | Task | Type | Duration | Start | Finish | Predecessors | Complete | Remaining | Total slack | Free slack | Constraint | Resources | Work | Actual work |
| --- | --- | --- | --- | --- | --- | --- | --- | --- | --- | --- | --- | --- | --- | --- | --- |
| 1 | 1 | Civil construction: BH1 floor ready | milestone | 0mo | 2015-11-02 | 2015-11-02 |  |  |  | 326d | 0d | start no earlier than 2015-11-02 |  |  |  |
| 2 | 2 | Ion Source / Terminal West ready for connection to LEBT | milestone | 0mo | 2016-07-04 | 2016-07-04 |  |  |  | 251d |  | start no earlier than 2016-07-04 |  |  |  |
| 3 | 7.1.2 | **Compact-LEBT (ehem. UNILAC-Upgrade / System-Design)** |  | 1145d? | 2013-01-29 A | 2017-06-19 |  | 3% | 1111.72d? | 0d |  |  |  | 71593.6h | 1152h |
| 4 | 7.1.2.1 | **Beam Dynamics** |  | 340d | 2013-11-04 A | 2015-02-20 |  | 31% | 234.48d | 606d |  |  |  | 2944h | 1152h |
| 5 | 7.1.2.1 | **general layout, preliminary** |  | 340d | 2013-11-04 A | 2015-02-20 |  | 53% | 160d | 606d |  |  |  | 1536h | 1152h |
| 6 | 3.1.1.1 | Conceptual Design I (simulations part. dyn.) |  | 9mo | 2013-11-04 A | 2014-07-11 A |  | 100% |  |  |  | start no earlier than 2013-11-04 | LOLI_Scientist [80%] | 1152h | 1152h |
| 7 | 3.1.1.2 | Conceptual Design II (def. of components) |  | 8mo | 2014-07-14 | 2015-02-20 | 6 |  |  | 606d | 0d |  | LOLI_Scientist [80%] | 384h |  |
| 8 | 3.1.1.3 | CDR accepted | milestone | 0mo | 2015-02-20 | 2015-02-20 | 7 |  |  | 606d |  |  |  |  |  |
| 9 | 7.1.2.1 | **layout based on final measured emittance** |  | 299d | 2013-12-31 | 2015-02-20 |  |  |  | 145d | 0d | start no earlier than 2013-12-31 |  | 1408h |  |
| 10 | 3.1.2.1 | simulations |  | 6mo | 2014-09-08 | 2015-02-20 |  |  |  | 145d |  | finish no earlier than 2015-02-20 | LOLI_Scientist [80%] | 768h |  |
| 11 | 3.1.2.2 | def. of components (incl. QQ-old modifications) |  | 6mo | 2013-12-31 | 2014-06-16 |  |  |  | 324d | 0d |  | LOLI_Scientist [80%]; ENMA_Scientist [80%] | 640h |  |
| 12 | 3.1.2.3 | FDR accepted | milestone | 0mo | 2014-06-16 | 2014-06-16 | 11 |  |  | 324d | 0d |  |  |  |  |
| 13 | 7.1.2.2 | **Magnets** |  | 640d? | 2014-06-17 | 2016-11-28 |  |  |  | 145d |  |  |  | 18624h |  |
| 14 | 3.2.1 | **Quadrupoles** |  | 640d? | 2014-06-17 | 2016-11-28 |  |  |  | 145d |  |  |  | 9024h |  |
| 15 | 7.1.2.2 | **QQ old UCL QQ1** |  | 459d | 2014-06-17 | 2016-03-18 |  |  |  | 326d |  |  |  | 2560h |  |
| 16 | 3.2.1.1.1 | Design of modifications | inactive | 6mo | 2015-02-23 | 2015-08-07 | 9 |  |  | 486d |  |  | ENMA_Scientist [80%] | 768h |  |
| 17 | 3.2.1.1.2 | Manufacturing modified parts |  | 4mo | 2014-06-17 | 2014-10-06 | 12 |  |  | 605d | 279d |  | CSTI_Mechanic [80%]; CSTI_Technician [80%]; ENMD_Engineer (Bachelor) [80%] | 1536h |  |
| 18 | 3.2.1.1.3 | Assembly and alignment |  | 3mo | 2015-11-02 | 2016-01-22 | 17, 1 |  |  | 326d | 0d |  | CSTI_Mechanic [80%]; CSTI_Technician [80%] | 768h |  |
| 19 | 3.2.1.1.4 | Commissioning without beam |  | 2mo | 2016-01-25 | 2016-03-18 | 18 |  |  | 326d | 0d |  | LOLI_Scientist [80%] | 256h |  |
| 20 | 3.2.1.1.5 | Accepted without beam | milestone | 0mo | 2016-03-18 | 2016-03-18 | 19 |  |  | 326d |  |  |  |  |  |
| 21 | 7.1.2.2 | **QQ new UH2QQ1** |  | 295d | 2015-03-02 | 2016-04-15 |  |  |  | 306d |  |  |  | 1984h |  |
| 22 | 7.1.2.2 | **Quadruplet Sigmaphi (incl. carrier frame)** |  | 70d | 2016-01-11 | 2016-04-15 |  |  |  | 306d |  | start no earlier than 2013-01-29 |  | 832h |  |
| 23 | 7.1.2.2.1 | Preparations Field mapping | inactive | 4mo | 2013-01-29 | 2013-05-20 |  |  |  | 1055d | 119d | start no earlier than 2013-01-29 | ENMA_Scientist [80%] | 512h |  |
| 24 | 7.1.2.2.2 | Field mapping | inactive | 0.5mo | 2013-11-04 | 2013-11-15 | 23 |  |  | 936d |  | start no earlier than 2013-11-04 | ENMA_Scientist [80%] | 64h |  |
| 25 | 7.1.2.2.3 | assembly in beam line | inactive | 3mo | 2015-09-14 | 2015-12-04 |  |  |  | 401d |  | start no earlier than 2015-09-14 | LOLI_Engineer (Master) [80%] | 384h |  |
| 26 | 7.1.2.2.4 | connection coil tubes | inactive | 1mo | 2015-11-09 | 2015-12-04 |  |  |  | 381d | 25d | start no earlier than 2015-11-09 | LOLI_Engineer (Master) [80%] | 128h |  |
| 27 | 7.1.2.2.5 | cabling EET | inactive | 1mo | 2016-01-11 | 2016-02-05 | 26 |  |  | 356d |  | start no earlier than 2016-01-11 | LOLI_Engineer (Master) [80%] | 128h |  |
| 28 | 7.1.2.2.6 | water connection | inactive | 1mo | 2016-01-11 | 2016-02-05 | 26 |  |  | 356d |  | start no earlier than 2016-01-11 | LOLI_Engineer (Master) [80%] | 128h |  |
| 29 | 7.1.2.2.7 | Assembly and alignment |  | 3mo | 2016-01-11 | 2016-04-01 |  |  |  | 306d | 0d | start no earlier than 2016-01-11 | CSTI_Mechanic [80%]; CSTI_Technician [80%] | 768h |  |
| 30 | 7.1.2.2.8 | commissioning without beam |  | 0.5mo | 2016-04-04 | 2016-04-15 | 29 |  |  | 306d | 0d | start no earlier than 2016-02-08 | LOLI_Scientist [80%] | 64h |  |

| ID | WBS | Task | Type | Duration | Start | Finish | Predecessors | Total slack | Free slack | Constraint | Resources | Work |
| --- | --- | --- | --- | --- | --- | --- | --- | --- | --- | --- | --- | --- |
| 31 | 7.1.2.2 | **Carrier frame adaption QQ new** | inactive | 154d | 2013-02-19 | 2013-09-20 |  | 976d |  |  |  | 768h |
| 32 | 7.1.2.2.1 | design | inactive | 1mo | 2013-02-19 | 2013-03-18 |  | 1110d |  | start no earlier than 2013-02-19 | LOLI_Engineer (Master) [80%] | 128h |
| 33 | 7.1.2.2.2 | Manufacturing incl. Testing (Manuf. finished 30.10.13) | inactive | 5mo | 2013-05-06 | 2013-09-20 |  | 976d |  | start no earlier than 2013-05-06 | LOLI_Engineer (Master) [80%] | 640h |
| 34 | 7.1.2.2 | **Connection box QQ new** |  | 200d | 2015-03-02 | 2015-12-04 |  | 401d |  |  |  | 1152h |
| 35 | 3.2.1.2.3.1 | design (with new cables) and prepare contract |  | 4mo | 2015-03-02 | 2015-06-19 |  | 401d | 0d | start no earlier than 2015-03-02 | ENMD_Engineer (Bachelor) [80%] | 512h |
| 36 | 3.2.1.2.3.2 | Contract is signed | milestone | 0mo | 2015-06-19 | 2015-06-19 | 35 | 401d | 0d |  |  |  |
| 37 | 3.2.1.2.3.3 | FDR |  | 2mo | 2015-06-22 | 2015-08-14 | 36 | 401d | 0d |  | LOLI_Scientist [80%] | 256h |
| 38 | 3.2.1.2.3.4 | Manufacturing incl. Testing |  | 2mo | 2015-08-17 | 2015-10-09 | 37 | 401d | 0d |  |  |  |
| 39 | 3.2.1.2.3.5 | Assembly and alignment |  | 1mo | 2015-10-12 | 2015-11-06 | 38 | 401d | 0d |  | CSTI_Mechanic [80%]; CSTI_Technician [80%] | 256h |
| 40 | 3.2.1.2.3.6 | Commissioning without beam |  | 1mo | 2015-11-09 | 2015-12-04 | 39 | 401d | 95d |  | LOLI_Scientist [80%] | 128h |
| 41 | 3.2.1.3 | Assembly in tunnel |  | 3mo | 2015-11-23 | 2016-02-12 |  | 351d |  | start no earlier than 2015-11-23 | CSTI_Mechanic [80%]; CSTI_Technician [80%] | 768h |
| 42 | 3.2.1.4 | Commissioning finished | milestone | 0d | 2016-04-15 | 2016-04-15 | 30, 40 | 306d |  |  |  |  |
| 43 | 7.1.2.2 | **QT new UCL** |  | 461d? | 2015-02-23 | 2016-11-28 |  | 145d |  | start no earlier than 2015-02-02 |  | 3712h |
| 44 | 3.2.1.5.1 | parameters defining |  | 6mo | 2015-02-23 | 2015-08-07 | 9 | 145d | 0d |  | ENMA_Scientist [80%]; LOIS_Scientist [80%] | 1536h |
| 45 | 3.2.1.5.2 | tendering (functional spec.) |  | 1mo | 2015-08-10 | 2015-09-04 | 44 | 145d | 0d |  | ENMA_Scientist [80%]; ENMI_Engineer (Master) [80%] | 256h |
| 46 | 3.2.1.5.3 | evaluation of tendering |  | 3mo | 2015-09-07 | 2015-11-27 | 45 | 145d | 0d |  | ENMA_Scientist [80%]; ENMI_Engineer (Master) [80%] | 768h |
| 47 | 3.2.1.5.4 | design work (by contractor) |  | 1mo | 2015-11-30 | 2015-12-25 | 46 | 145d | 0d |  |  |  |
| 48 | 3.2.1.5.5 | manufacturing |  | 6mo | 2015-12-28 | 2016-06-10 | 47 | 145d | 0d |  |  |  |
| 49 | 3.2.1.5.6 | Assembly and alignment |  | 3mo | 2016-06-13 | 2016-09-02 | 48 | 145d | 0d |  | CSTI_Mechanic [80%]; CSTI_Technician [80%] | 768h |
| 50 | 3.2.1.5.7 | Commissioning without beam |  | 3mo | 2016-09-05 | 2016-11-25 | 49 | 145d | 0d |  | LOLI_Scientist [80%] | 384h |
| 51 | 3.2.1.5.8 | Commissioning finished |  | 0.05mo? | 2016-11-28 | 2016-11-28 | 50 | 145d |  |  |  |  |
| 52 | 3.2.2 | **Steerer magnets** |  | 355d | 2015-02-16 | 2016-06-24 |  | 256d |  |  |  | 9600h |
| 53 | 7.1.2.2 | **Switching magnet UH1 MU1+MS1** |  | 200d | 2015-02-16 | 2015-11-20 |  | 411d |  |  |  | 3840h |
| 54 | 3.2.2.1.1 | **vacuum chamber** |  | 200d | 2015-02-16 | 2015-11-20 |  | 411d |  | start no earlier than 2014-10-06 |  | 1920h |
| 55 | 3.2.2.1.1.1 | Specification |  | 3mo | 2015-02-16 | 2015-05-08 |  | 411d | 0d | start no earlier than 2015-02-16 | ENMA_Scientist [80%]; ENMI_Engineer (Master) [80%] | 768h |
| 56 | 3.2.2.1.1.2 | Tendering |  | 2mo | 2015-05-11 | 2015-07-03 | 55 | 411d | 0d |  | ENMA_Scientist [80%]; ENMI_Engineer (Master) [80%] | 512h |
| 57 | 3.2.2.1.1.3 | Manufacturing incl. Testing |  | 2mo | 2015-07-06 | 2015-08-28 | 56 | 411d | 0d |  |  |  |
| 58 | 3.2.2.1.1.4 | Assembly and alignment |  | 2mo | 2015-08-31 | 2015-10-23 | 57 | 411d | 0d |  | CSTI_Mechanic [80%]; CSTI_Technician [80%] | 512h |
| 59 | 3.2.2.1.1.5 | Commissioning without beam |  | 1mo | 2015-10-26 | 2015-11-20 | 58 | 411d |  |  | LOLI_Scientist [80%] | 128h |

| ID | WBS | Task | Duration | Start | Finish | Predecessors | Total slack | Free slack | Constraint | Resources | Work |
| --- | --- | --- | --- | --- | --- | --- | --- | --- | --- | --- | --- |
| 60 | 3.2.2.1.2 | **magnets** | 200d | 2015-02-16 | 2015-11-20 |  | 411d |  | start no earlier than 2014-10-06 |  | 1920h |
| 61 | 3.2.2.1.2.1 | Specification | 3mo | 2015-02-16 | 2015-05-08 |  | 411d | 0d | start no earlier than 2015-02-16 | ENMA_Scientist [80%]; ENMI_Engineer (Master) [80%] | 768h |
| 62 | 3.2.2.1.2.2 | Tendering | 2mo | 2015-05-11 | 2015-07-03 | 61 | 411d | 0d |  | ENMA_Scientist [80%]; ENMI_Engineer (Master) [80%] | 512h |
| 63 | 3.2.2.1.2.3 | Manufacturing incl. Testing | 2mo | 2015-07-06 | 2015-08-28 | 62 | 411d | 0d |  |  |  |
| 64 | 3.2.2.1.2.4 | Assembly and alignment | 2mo | 2015-08-31 | 2015-10-23 | 63 | 411d | 0d |  | CSTI_Mechanic [80%]; CSTI_Technician [80%] | 512h |
| 65 | 3.2.2.1.2.5 | Commissioning without beam | 1mo | 2015-10-26 | 2015-11-20 | 64 | 411d |  |  | LOLI_Scientist [80%] | 128h |
| 66 | 3.2.2.2 | **Steerers** | 200d | 2015-09-21 | 2016-06-24 |  | 256d |  |  |  | 5760h |
| 67 | 7.1.2.2 | **Steerer UH1MS2** | 200d | 2015-09-21 | 2016-06-24 |  | 256d |  | start no earlier than 2014-10-06 |  | 1920h |
| 68 | 7.1.2.2 | Specification | 3mo | 2015-09-21 | 2015-12-11 |  | 256d | 0d | start no earlier than 2015-09-21 | ENMA_Scientist [80%]; ENMI_Engineer (Master) [80%] | 768h |
| 69 | 7.1.2.2 | Tendering | 2mo | 2015-12-14 | 2016-02-05 | 68 | 256d | 0d |  | ENMA_Scientist [80%]; ENMI_Engineer (Master) [80%] | 512h |
| 70 | 7.1.2.2 | Manufacturing incl. Testing | 2mo | 2016-02-08 | 2016-04-01 | 69 | 256d | 0d |  |  |  |
| 71 | 7.1.2.2 | Assembly and alignment | 2mo | 2016-04-04 | 2016-05-27 | 70 | 256d | 0d |  | CSTI_Mechanic [80%]; CSTI_Technician [80%] | 512h |
| 72 | 7.1.2.2 | Commissioning without beam | 1mo | 2016-05-30 | 2016-06-24 | 71 | 256d |  |  | LOLI_Scientist [80%] | 128h |
| 73 | 7.1.2.2 | **1st UCL steerer** | 200d | 2015-09-21 | 2016-06-24 |  | 256d |  |  |  | 1920h |
| 74 | 3.2.2.2.2.1 | Specification | 3mo | 2015-09-21 | 2015-12-11 |  | 256d | 0d | start no earlier than 2015-09-21 | ENMA_Scientist [80%]; ENMI_Engineer (Master) [80%] | 768h |
| 75 | 3.2.2.2.2.2 | Tendering | 2mo | 2015-12-14 | 2016-02-05 | 74 | 256d | 0d |  | ENMA_Scientist [80%]; ENMI_Engineer (Master) [80%] | 512h |
| 76 | 3.2.2.2.2.3 | Manufacturing incl. Testing | 2mo | 2016-02-08 | 2016-04-01 | 75 | 256d | 0d |  |  |  |
| 77 | 3.2.2.2.2.4 | Assembly and alignment | 2mo | 2016-04-04 | 2016-05-27 | 76 | 256d | 0d |  | CSTI_Mechanic [80%]; CSTI_Technician [80%] | 512h |
| 78 | 3.2.2.2.2.5 | Commissioning without beam | 1mo | 2016-05-30 | 2016-06-24 | 77 | 256d |  |  | LOLI_Scientist [80%] | 128h |
| 79 | 7.1.2.2 | **2nd UCL steerer** | 200d | 2015-09-21 | 2016-06-24 |  | 256d |  | start no earlier than 2015-09-21 |  | 1920h |
| 80 | 3.2.2.2.3.1 | Specification | 3mo | 2015-09-21 | 2015-12-11 |  | 256d | 0d | start no earlier than 2015-09-21 | ENMA_Scientist [80%]; ENMI_Engineer (Master) [80%] | 768h |
| 81 | 3.2.2.2.3.2 | Tendering | 2mo | 2015-12-14 | 2016-02-05 | 80 | 256d | 0d |  | ENMA_Scientist [80%]; ENMI_Engineer (Master) [80%] | 512h |
| 82 | 3.2.2.2.3.3 | Manufacturing incl. Testing | 2mo | 2016-02-08 | 2016-04-01 | 81 | 256d | 0d |  |  |  |
| 83 | 3.2.2.2.3.4 | Assembly and alignment | 2mo | 2016-04-04 | 2016-05-27 | 82 | 256d | 0d |  | CSTI_Mechanic [80%]; CSTI_Technician [80%] | 512h |
| 84 | 3.2.2.2.3.5 | Commissioning without beam | 1mo | 2016-05-30 | 2016-06-24 | 83 | 256d |  |  | LOLI_Scientist [80%] | 128h |

| ID | WBS | Task | Duration | Start | Finish | Predecessors | Total slack | Free slack | Constraint | Resources | Work |
| --- | --- | --- | --- | --- | --- | --- | --- | --- | --- | --- | --- |
| 85 | 7.1.2.3 | **Power Convertors** | 406d? | 2014-11-17 | 2016-06-06 |  | 270d |  |  |  | 9241.6h |
| 86 | 7.1.2.3 | **PS UH2QQ1** | 406d | 2014-11-17 | 2016-06-06 |  | 270d |  | start no earlier than 2014-11-17 |  | 1536h |
| 87 | 3.3.1.1 | layout according to real meas. inductivity | 1mo | 2014-11-17 | 2014-12-12 |  | 656d |  | finish no earlier than 2014-12-12 | LOEP_Engineer (Master) [80%]; LOEP_Technician [80%] | 256h |
| 88 | 3.3.1.2 | Tendering ted.europa | 1mo | 2015-01-20 | 2015-02-16 |  | 270d | 0d | start no earlier than 2015-01-20 | LOEP_Engineer (Master) [80%]; LOEP_Technician [80%] | 256h |
| 89 | 3.3.1.3 | evaluation of tendering | 2mo | 2015-02-17 | 2015-04-13 | 88 | 270d | 0d |  | LOEP_Engineer (Master) [80%]; LOEP_Technician [80%] | 512h |
| 90 | 3.3.1.4 | Manufacturing incl. Testing | 13mo | 2015-04-14 | 2016-04-11 | 89 | 270d | 0d |  |  |  |
| 91 | 3.3.1.5 | Assembly on site | 1mo | 2016-04-12 | 2016-05-09 | 90 | 270d | 0d |  | CSTI_Mechanic [80%]; CSTI_Technician [80%] | 256h |
| 92 | 3.3.1.6 | Commissioning without beam (SAT MNG) | 1mo | 2016-05-10 | 2016-06-06 | 91 | 270d |  |  | LOLI_Scientist [80%]; LOEP_Engineer (Master) [80%] | 256h |
| 93 | 7.1.2.3 | **PS QT new** | 200d | 2015-04-06 | 2016-01-08 |  | 376d |  | start no earlier than 2015-04-06 |  | 1920h |
| 94 | 3.3.2.1 | Specification | 3mo | 2015-04-06 | 2015-06-26 |  | 376d | 0d |  | LOEP_Engineer (Master) [80%]; LOEP_Technician [80%] | 768h |
| 95 | 3.3.2.2 | Tendering | 2mo | 2015-06-29 | 2015-08-21 | 94 | 376d | 0d |  | LOEP_Engineer (Master) [80%]; LOEP_Technician [80%] | 512h |
| 96 | 3.3.2.3 | Manufacturing incl. Testing | 2mo | 2015-08-24 | 2015-10-16 | 95 | 376d | 0d |  |  |  |
| 97 | 3.3.2.4 | Assembly and alignment | 2mo | 2015-10-19 | 2015-12-11 | 96 | 376d | 0d |  | CSTI_Mechanic [80%]; CSTI_Technician [80%] | 512h |
| 98 | 3.3.2.5 | Commissioning without beam | 1mo | 2015-12-14 | 2016-01-08 | 97 | 376d |  |  | LOLI_Scientist [80%] | 128h |
| 99 | 7.1.2.3 | **PS UH1MU1+MS1** | 200d | 2015-03-23 | 2015-12-25 |  | 386d |  | start no earlier than 2015-03-23 |  | 1920h |
| 100 | 3.3.3.1 | Specification | 3mo | 2015-03-23 | 2015-06-12 |  | 386d | 0d | start no earlier than 2015-03-23 | LOEP_Engineer (Master) [80%]; LOEP_Technician [80%] | 768h |
| 101 | 3.3.3.2 | Tendering | 2mo | 2015-06-15 | 2015-08-07 | 100 | 386d | 0d |  | LOEP_Engineer (Master) [80%]; LOEP_Technician [80%] | 512h |
| 102 | 3.3.3.3 | Manufacturing incl. Testing | 2mo | 2015-08-10 | 2015-10-02 | 101 | 386d | 0d |  |  |  |
| 103 | 3.3.3.4 | Assembly and alignment | 2mo | 2015-10-05 | 2015-11-27 | 102 | 386d | 0d |  | CSTI_Mechanic [80%]; CSTI_Technician [80%] | 512h |
| 104 | 3.3.3.5 | Commissioning without beam | 1mo | 2015-11-30 | 2015-12-25 | 103 | 386d |  |  | LOLI_Scientist [80%] | 128h |
| 105 | 7.1.2.3 | **PS UH1MS2** | 1d? | 2015-04-06 | 2015-04-06 |  | 575d |  | start no earlier than 2015-04-06 |  | 25.6h |
| 106 | 7.1.2.3 | Adaption of existing power supplies | 0.05mo? | 2015-04-06 | 2015-04-06 |  | 575d |  |  | CSTI_Mechanic [80%]; CSTI_Technician [80%]; LOEP_Engineer (Master) [80%]; LOEP_Technician [80%] | 25.6h |
| 107 | 7.1.2.3 | **PS 1st UCL steerer** | 200d | 2015-06-29 | 2016-04-01 |  | 316d |  | start no earlier than 2015-04-06 |  | 1920h |
| 108 | 3.3.5.1 | Specification | 3mo | 2015-06-29 | 2015-09-18 |  | 316d | 0d | start no earlier than 2015-06-29 | LOEP_Engineer (Master) [80%]; LOEP_Technician [80%] | 768h |
| 109 | 3.3.5.2 | Tendering | 2mo | 2015-09-21 | 2015-11-13 | 108 | 316d | 0d |  | LOEP_Engineer (Master) [80%]; LOEP_Technician [80%] | 512h |
| 110 | 3.3.5.3 | Manufacturing incl. Testing | 2mo | 2015-11-16 | 2016-01-08 | 109 | 316d | 0d |  |  |  |
| 111 | 3.3.5.4 | Assembly and alignment | 2mo | 2016-01-11 | 2016-03-04 | 110 | 316d | 0d |  | CSTI_Mechanic [80%]; CSTI_Technician [80%] | 512h |
| 112 | 3.3.5.5 | Commissioning without beam | 1mo | 2016-03-07 | 2016-04-01 | 111 | 316d |  |  | LOLI_Scientist [80%] | 128h |

| ID | WBS | Task | Type | Duration | Start | Finish | Predecessors | Total slack | Free slack | Constraint | Resources | Work |
| --- | --- | --- | --- | --- | --- | --- | --- | --- | --- | --- | --- | --- |
| 113 | 7.1.2.3 | **PS 2nd UCL steerer** |  | 200d | 2015-06-29 | 2016-04-01 |  | 316d |  | start no earlier than 2015-04-06 |  | 1920h |
| 114 | 3.3.6.1 | Specification |  | 3mo | 2015-06-29 | 2015-09-18 |  | 316d | 0d | start no earlier than 2015-06-29 | LOEP_Engineer (Master) [80%]; LOEP_Technician [80%] | 768h |
| 115 | 3.3.6.2 | Tendering |  | 2mo | 2015-09-21 | 2015-11-13 | 114 | 316d | 0d |  | LOEP_Engineer (Master) [80%]; LOEP_Technician [80%] | 512h |
| 116 | 3.3.6.3 | Manufacturing incl. Testing |  | 2mo | 2015-11-16 | 2016-01-08 | 115 | 316d | 0d |  |  |  |
| 117 | 3.3.6.4 | Assembly and alignment |  | 2mo | 2016-01-11 | 2016-03-04 | 116 | 316d | 0d |  | CSTI_Mechanic [80%]; CSTI_Technician [80%] | 512h |
| 118 | 3.3.6.5 | Commissioning without beam |  | 1mo | 2016-03-07 | 2016-04-01 | 117 | 316d |  |  | LOLI_Scientist [80%] | 128h |
| 119 | 3.4 | **Beam Diagnostics** |  | 240d | 2015-03-02 | 2016-01-29 |  | 361d |  |  |  | 29184h |
| 120 | 7.1.2.6 | Aperture collimator (at 2556 mm) |  | 9mo | 2015-03-02 | 2015-11-06 |  | 421d |  | start no earlier than 2015-03-02 | LOBI_Engineer (Bachelor) [80%]; LOBI_Mechanic [80%]; LOBI_Scientist [80%]; LOBI_Technician [80%] | 4608h |
| 121 | 7.1.2.6 | Diagnostic chambers |  | 12mo | 2015-03-02 | 2016-01-29 |  | 361d |  | start no earlier than 2015-03-02 | LOBI_Engineer (Bachelor) [80%]; LOBI_Mechanic [80%]; LOBI_Scientist [80%]; LOBI_Technician [80%] | 6144h |
| 122 | 7.1.2.6 | Profile grid |  | 12mo | 2015-03-02 | 2016-01-29 |  | 361d |  | start no earlier than 2015-03-02 | LOBI_Engineer (Bachelor) [80%]; LOBI_Mechanic [80%]; LOBI_Scientist [80%]; LOBI_Technician [80%] | 6144h |
| 123 | 7.1.2.6 | Trafos |  | 12mo | 2015-03-02 | 2016-01-29 |  | 361d |  | start no earlier than 2015-03-02 | LOBI_Engineer (Bachelor) [80%]; LOBI_Mechanic [80%]; LOBI_Scientist [80%]; LOBI_Technician [80%] | 6144h |
| 124 | 7.1.2.6 | Faraday Cups (80 mm diam.), 2x |  | 12mo | 2015-03-02 | 2016-01-29 |  | 361d |  | start no earlier than 2015-03-02 | LOBI_Engineer (Bachelor) [80%]; LOBI_Mechanic [80%]; LOBI_Scientist [80%]; LOBI_Technician [80%] | 6144h |
| 125 | 7.1.2.6 | **Vacuum** |  | 180d | 2015-05-04 | 2016-01-08 |  | 376d |  |  |  | 4480h |
| 126 | 3.5.1 | Vacuum equipment design |  | 2mo | 2015-05-04 | 2015-06-26 |  | 516d |  | start no earlier than 2015-05-04 | CSVS_Technician [80%] | 256h |
| 127 | 3.5.2 | Turbo pumps |  | 6mo | 2015-05-04 | 2015-10-16 |  | 436d |  | start no earlier than 2015-05-04 | CSVS_Technician [80%] | 768h |
| 128 | 3.5.3 | Ion Getter pumps |  | 6mo | 2015-05-04 | 2015-10-16 |  | 436d |  | start no earlier than 2015-05-04 | CSVS_Technician [80%] | 768h |
| 129 | 3.5.4 | Valves |  | 6mo | 2015-05-04 | 2015-10-16 |  | 436d |  | start no earlier than 2015-05-04 | CSVS_Technician [80%] | 768h |
| 130 | 3.5.5 | Vacuum diagnostics |  | 6mo | 2015-05-04 | 2015-10-16 |  | 436d |  | start no earlier than 2015-05-04 | CSVS_Technician [80%] | 768h |
| 131 | 3.5.6 | Support frames |  | 9mo | 2015-05-04 | 2016-01-08 |  | 376d |  | start no earlier than 2015-05-04 | CSTI_Mechanic [80%] | 1152h |
| 132 | 3.6 | **Media Supply** |  | 100d | 2015-05-04 | 2015-09-18 |  | 456d |  |  |  | 896h |
| 133 | 3.6.1 | design |  | 2mo | 2015-05-04 | 2015-06-26 |  | 516d |  | start no earlier than 2015-05-04 | VT_Engineer [80%] | 256h |
| 134 | 3.6.2 | manufactoring / purchase |  | 5mo | 2015-05-04 | 2015-09-18 |  | 456d |  | start no earlier than 2015-05-04 | VT_Engineer [80%] | 640h |
| 135 | 3.7 | **Controls** |  | 160d | 2015-05-04 | 2015-12-11 |  | 396d |  |  |  | 1280h |
| 136 | 3.7.1 | design |  | 2mo | 2015-05-04 | 2015-06-26 |  | 516d |  | start no earlier than 2015-05-04 | CSCO_Engineer (Master) [80%] | 256h |
| 137 | 3.7.2 | electronics |  | 8mo | 2015-05-04 | 2015-12-11 |  | 396d |  | start no earlier than 2015-05-04 | CSCO_Engineer (Master) [80%] | 1024h |
| 138 | 7.1.2.6 | evtl. Diagnostics before first QQ | inactive | 12mo | 2015-03-02 | 2016-01-29 |  | 361d |  | start no earlier than 2015-03-02 |  |  |

Notes:
- 124: C. Dorn

| ID | WBS | Task | Type | Duration | Start | Finish | Predecessors | Total slack | Free slack | Constraint | Resources | Work |
| --- | --- | --- | --- | --- | --- | --- | --- | --- | --- | --- | --- | --- |
| 140 | 7.1.2.6 | **Hosti-measurements Emi/Cup for preparation** |  | 0d? | 2013-01-29 | 2013-01-29 |  | 0d |  | start no earlier than 2013-01-29 |  |  |
| 141 | 7.1.2.6 | Emittance measurements | inactive | 5mo | 2013-01-29 | 2013-06-17 |  | 1005d | 0d |  |  |  |
| 142 | 7.1.2.6 | Beam current meas. with Cup | inactive | 0.5mo | 2013-06-18 | 2013-07-01 | 141 | 1015d | 10d |  |  |  |
| 143 | 7.1.2.6 | Evaluation of meas. | inactive | 1mo | 2013-07-16 | 2013-08-12 | 141FS+1mo, 142 | 1005d |  |  |  |  |
| 144 | 3.9 | **Civil Construction** |  | 0d? | 2013-01-29 | 2013-01-29 |  | 1145d |  |  |  |  |
| 145 | 7.1.2.11 | building / carrier frames | inactive | 9mo | 2013-01-29 | 2013-10-07 |  | 965d |  |  |  |  |
| 146 | 7.1.2.11 | electronics | inactive | 0.05mo? | 2013-01-29 | 2013-01-29 |  | 1144d |  |  |  |  |
| 147 | 7.1.2.11 | controls | inactive | 6mo | 2013-01-29 | 2013-07-15 |  | 1025d |  |  |  |  |
| 148 | 7.1.2.8 | **Terminal West (Ion Source Department LOIS)** |  | 266d? | 2016-06-13 | 2017-06-19 |  | 0d |  |  | LOIS_Scientist | 4944h |
| 149 | 7.1.2.8 | **Faradayraum Mitte** | inactive | 1d? | 2013-01-29 | 2013-01-29 |  | 1144d |  |  |  |  |
| 150 | 3.10.1.1 | Contract preparation incl. Spec compilation | inactive | 0.05mo? | 2013-01-29 | 2013-01-29 |  | 1144d |  |  |  |  |
| 151 | 3.10.1.2 | Preparation of series production | inactive | 0.05mo? | 2013-01-29 | 2013-01-29 |  | 1144d |  |  |  |  |
| 152 | 3.10.1.3 | Manufacturing incl. Testing | inactive | 0.05mo? | 2013-01-29 | 2013-01-29 |  | 1144d |  |  |  |  |
| 153 | 3.10.1.4 | Assembly and alignment | inactive | 0.05mo? | 2013-01-29 | 2013-01-29 |  | 1144d |  |  |  |  |
| 154 | 3.10.1.5 | Commissioning without beam | inactive | 0.05mo? | 2013-01-29 | 2013-01-29 |  | 1144d |  |  |  |  |
| 155 | 7.1.2.8 | **Trenntrafo Faradayraum** | inactive | 1d? | 2013-01-29 | 2013-01-29 |  | 1144d |  |  |  |  |
| 156 | 3.10.2.1 | Contract preparation incl. Spec compilation | inactive | 0.05mo? | 2013-01-29 | 2013-01-29 |  | 1144d |  |  |  |  |
| 157 | 3.10.2.2 | Preparation of series production | inactive | 0.05mo? | 2013-01-29 | 2013-01-29 |  | 1144d |  |  |  |  |
| 158 | 3.10.2.3 | Manufacturing incl. Testing | inactive | 0.05mo? | 2013-01-29 | 2013-01-29 |  | 1144d |  |  |  |  |
| 159 | 3.10.2.4 | Assembly and alignment | inactive | 0.05mo? | 2013-01-29 | 2013-01-29 |  | 1144d |  |  |  |  |
| 160 | 3.10.2.5 | Commissioning without beam | inactive | 0.05mo? | 2013-01-29 | 2013-01-29 |  | 1144d |  |  |  |  |
| 161 | 7.1.2.8 | **High voltage platform** | inactive | 1d? | 2013-01-29 | 2013-01-29 |  | 1144d |  |  |  |  |
| 162 | 3.10.3.1 | Contract preparation incl. Spec compilation | inactive | 0.05mo? | 2013-01-29 | 2013-01-29 |  | 1144d |  |  |  |  |
| 163 | 3.10.3.2 | Preparation of series production | inactive | 0.05mo? | 2013-01-29 | 2013-01-29 |  | 1144d |  |  |  |  |
| 164 | 3.10.3.3 | Manufacturing incl. Testing | inactive | 0.05mo? | 2013-01-29 | 2013-01-29 |  | 1144d |  |  |  |  |
| 165 | 3.10.3.4 | Assembly and alignment | inactive | 0.05mo? | 2013-01-29 | 2013-01-29 |  | 1144d |  |  |  |  |
| 166 | 3.10.3.5 | Commissioning without beam | inactive | 0.05mo? | 2013-01-29 | 2013-01-29 |  | 1144d |  |  |  |  |

| ID | WBS | Task | Type | Duration | Start | Finish | Total slack |
| --- | --- | --- | --- | --- | --- | --- | --- |
| 167 | 7.1.2.8 | **Ion source** | inactive | 1d? | 2013-01-29 | 2013-01-29 | 1144d |
| 168 | 3.10.4.1 | Contract preparation incl. Spec compilation | inactive | 0.05mo? | 2013-01-29 | 2013-01-29 | 1144d |
| 169 | 3.10.4.2 | Preparation of series production | inactive | 0.05mo? | 2013-01-29 | 2013-01-29 | 1144d |
| 170 | 3.10.4.3 | Manufacturing incl. Testing | inactive | 0.05mo? | 2013-01-29 | 2013-01-29 | 1144d |
| 171 | 3.10.4.4 | Assembly and alignment | inactive | 0.05mo? | 2013-01-29 | 2013-01-29 | 1144d |
| 172 | 3.10.4.5 | Commissioning without beam | inactive | 0.05mo? | 2013-01-29 | 2013-01-29 | 1144d |
| 173 | 7.1.2.8 | **Glove box** | inactive | 1d? | 2013-01-29 | 2013-01-29 | 1144d |
| 174 | 3.10.5.1 | Contract preparation incl. Spec compilation | inactive | 0.05mo? | 2013-01-29 | 2013-01-29 | 1144d |
| 175 | 3.10.5.2 | Preparation of series production | inactive | 0.05mo? | 2013-01-29 | 2013-01-29 | 1144d |
| 176 | 3.10.5.3 | Manufacturing incl. Testing | inactive | 0.05mo? | 2013-01-29 | 2013-01-29 | 1144d |
| 177 | 3.10.5.4 | Assembly and alignment | inactive | 0.05mo? | 2013-01-29 | 2013-01-29 | 1144d |
| 178 | 3.10.5.5 | Commissioning without beam | inactive | 0.05mo? | 2013-01-29 | 2013-01-29 | 1144d |
| 179 | 7.1.2.8 | **High voltage power supply** | inactive | 1d? | 2013-01-29 | 2013-01-29 | 1144d |
| 180 | 3.10.6.1 | Contract preparation incl. Spec compilation | inactive | 0.05mo? | 2013-01-29 | 2013-01-29 | 1144d |
| 181 | 3.10.6.2 | Preparation of series production | inactive | 0.05mo? | 2013-01-29 | 2013-01-29 | 1144d |
| 182 | 3.10.6.3 | Manufacturing incl. Testing | inactive | 0.05mo? | 2013-01-29 | 2013-01-29 | 1144d |
| 183 | 3.10.6.4 | Assembly and alignment | inactive | 0.05mo? | 2013-01-29 | 2013-01-29 | 1144d |
| 184 | 3.10.6.5 | Commissioning without beam | inactive | 0.05mo? | 2013-01-29 | 2013-01-29 | 1144d |
| 185 | 7.1.2.8 | **Vacuum** | inactive | 1d? | 2013-01-29 | 2013-01-29 | 1144d |
| 186 | 3.10.7.1 | Contract preparation incl. Spec compilation | inactive | 0.05mo? | 2013-01-29 | 2013-01-29 | 1144d |
| 187 | 3.10.7.2 | Preparation of series production | inactive | 0.05mo? | 2013-01-29 | 2013-01-29 | 1144d |
| 188 | 3.10.7.3 | Manufacturing incl. Testing | inactive | 0.05mo? | 2013-01-29 | 2013-01-29 | 1144d |
| 189 | 3.10.7.4 | Assembly and alignment | inactive | 0.05mo? | 2013-01-29 | 2013-01-29 | 1144d |
| 190 | 3.10.7.5 | Commissioning without beam | inactive | 0.05mo? | 2013-01-29 | 2013-01-29 | 1144d |

| ID | WBS | Task | Type | Duration | Start | Finish | Predecessors | Total slack | Constraint | Resources | Work |
| --- | --- | --- | --- | --- | --- | --- | --- | --- | --- | --- | --- |
| 191 | 3.10.8 | **Installation in Tunnel / Cave** |  | 201d | 2016-06-13 | 2017-03-20 |  | 65d |  |  | 2048h |
| 192 | 7.1.2.7 | Assembly position shift UL/UR5QT3 |  | 2mo | 2016-06-13 | 2016-08-05 | 48 | 226d | start no earlier than 2015-12-07 | CSTI_Mechanic [80%]; CSTI_Technician [80%] | 512h |
| 193 | 7.1.2.7 | LEBT Assembly |  | 6mo | 2016-10-04 | 2017-03-20 | 48 | 65d | start no earlier than 2016-10-04 | CSTI_Mechanic [80%]; CSTI_Technician [80%] | 1536h |
| 194 | 3.10.9 | **Commissioning Compact LEBT with Beam** |  | 121d? | 2017-01-02 | 2017-06-19 |  | 0d |  |  | 768h |
| 195 | 7.1.2.0 | Commissioning Compact LEBT with Beam |  | 6mo | 2017-01-02 | 2017-06-16 |  | 0d | start no earlier than 2017-01-02 | LOLI_Scientist [80%] | 768h |
| 196 | 3.10.9.2 | SAT Bb accepted / ready for operation |  | 0.05mo? | 2017-06-19 | 2017-06-19 | 195 | 0d |  |  |  |
| 197 | 4 | Contract preparation incl. Spec compilation | inactive | 0.05mo? | 2013-01-29 | 2013-01-29 |  | 1144d |  |  |  |
| 198 | 5 | Preparation of series production | inactive | 0.05mo? | 2013-01-29 | 2013-01-29 |  | 1144d |  |  |  |
| 199 | 6 | Manufacturing incl. Testing | inactive | 0.05mo? | 2013-01-29 | 2013-01-29 |  | 1144d |  |  |  |
| 200 | 7 | Assembly and alignment | inactive | 0.05mo? | 2013-01-29 | 2013-01-29 |  | 1144d |  |  |  |
| 201 | 8 | Commissioning without beam | inactive | 0.05mo? | 2013-01-29 | 2013-01-29 |  | 1144d |  |  |  |
